# Theater Renovation-solution

Schedule from MS Project, 2005-09-15 to 2005-11-08, costs in $.

## Calendars

- Standard: Mon-Fri 08:00-12:00, 13:00-17:00; Sat-Sun off.

## Resources

| Resource | Rate |
| --- | --- |
| Your name |  |
| General Contractor | 50 |
| Painters | 25 |
| Electricans | 35 |
| Plumbers | 35 |
| Demolition Team | 20 |
| Tiler | 40 |
| Carpenters | 20 |

## Schedule

| ID | WBS | Task | Duration | Start | Finish | Predecessors | Total slack | Free slack | Resources | Work | Cost |
| --- | --- | --- | --- | --- | --- | --- | --- | --- | --- | --- | --- |
| 1 | 1 | **General planning** | 3d | 2005-09-15 | 2005-09-19 |  | 0d |  |  | 32h | 1,400 |
| 2 | 1.1 | Interview contractors | 2d | 2005-09-15 | 2005-09-16 |  | 0d |  | Your name | 16h |  |
| 3 | 1.2 | Sign contract | 1d | 2005-09-19 | 2005-09-19 | 2 | 0d |  | General Contractor; Your name | 16h | 1,400 |
| 4 | 2 | **Demolition** | 4d | 2005-09-20 | 2005-09-23 | 1 | 0d |  |  | 96h | 1,920 |
| 5 | 2.1 | Stage | 2d | 2005-09-20 | 2005-09-21 | 3 | 2d |  | Demolition Team | 16h | 320 |
| 6 | 2.2 | Orchestra | 4d | 2005-09-20 | 2005-09-23 |  | 0d |  | Demolition Team | 32h | 640 |
| 7 | 2.3 | Lobby | 3d | 2005-09-20 | 2005-09-22 |  | 1d |  | Demolition Team | 24h | 480 |
| 8 | 2.4 | Restrooms | 3d | 2005-09-20 | 2005-09-22 |  | 1d |  | Demolition Team | 24h | 480 |
| 9 | 3 | **Electrical work** | 6d | 2005-09-26 | 2005-10-03 | 4 | 0d |  |  | 48h | 1,680 |
| 10 | 3.1 | Wiring | 3d | 2005-09-26 | 2005-09-28 |  | 0d |  | Electricans | 24h | 840 |
| 11 | 3.2 | Electrical Inspection | 3d | 2005-09-29 | 2005-10-03 | 10 | 0d |  | Electricans | 24h | 840 |
| 12 | 4 | **Framing, Insulation, Drywall, & Spackle** | 11d | 2005-10-04 | 2005-10-18 | 4, 9, 11 | 0d |  |  | 168h | 5,760 |
| 13 | 4.1 | Stage | 2.5d | 2005-10-04 | 2005-10-06 |  | 0d |  | General Contractor; Carpenters | 40h | 1,400 |
| 14 | 4.2 | Orchestra | 2.5d | 2005-10-06 | 2005-10-10 | 13 | 0d |  | General Contractor; Carpenters | 40h | 1,400 |
| 15 | 4.3 | Lobby | 5d | 2005-10-11 | 2005-10-17 | 14 | 0d |  | General Contractor; Carpenters | 80h | 2,800 |
| 16 | 4.4 | Construction Inspection | 1d | 2005-10-18 | 2005-10-18 | 15 | 0d |  | Carpenters | 8h | 160 |
| 17 | 5 | **Restrooms** | 7.5d | 2005-09-26 | 2005-10-05 | 4 | 9.5d |  |  | 80h | 2,940 |
| 18 | 5.1 | Framing, Insulation, Drywall | 2d | 2005-09-26 | 2005-09-27 |  | 9.5d | 0d | General Contractor; Carpenters | 32h | 1,120 |
| 19 | 5.2 | Plumbing | 3d | 2005-09-28 | 2005-09-30 | 18 | 9.5d | 0d | Plumbers | 24h | 840 |
| 20 | 5.3 | Tile | 2d | 2005-10-03 | 2005-10-04 | 19 | 9.5d | 0d | Tiler | 16h | 640 |
| 21 | 5.4 | Plumbing Inspection | 0.5d | 2005-10-05 | 2005-10-05 | 20 | 9.5d |  | General Contractor; Plumbers | 8h | 340 |
| 22 | 6 | **Painting** | 9d | 2005-10-19 | 2005-10-31 | 12 | 0d |  |  | 72h | 1,800 |
| 23 | 6.1 | Stage | 2d | 2005-10-19 | 2005-10-20 | 21 | 0d |  | Painters | 16h | 400 |
| 24 | 6.2 | Orchestra | 2d | 2005-10-21 | 2005-10-24 | 23 | 0d |  | Painters | 16h | 400 |
| 25 | 6.3 | Lobby | 2d | 2005-10-25 | 2005-10-26 | 24 | 0d |  | Painters | 16h | 400 |
| 26 | 6.4 | Restrooms | 3d | 2005-10-27 | 2005-10-31 | 25 | 0d |  | Painters | 24h | 600 |
| 27 | 7 | Final Inspections | 1d | 2005-11-01 | 2005-11-01 | 22 | 0d |  |  |  |  |

| ID | WBS | Task | Type | Duration | Start | Finish | Predecessors | Total slack | Resources | Work |
| --- | --- | --- | --- | --- | --- | --- | --- | --- | --- | --- |
| 28 | 8 | **Opening Day** |  | 2d | 2005-11-04 | 2005-11-08 | 27FS+3d | 0d | Your name | 56h |
| 29 | 8.1 | Order food |  | 1d | 2005-11-07 | 2005-11-07 |  | 1d | Your name | 8h |
| 30 | 8.2 | Organize entertainment |  | 2d | 2005-11-07 | 2005-11-08 |  | 0d | Your name | 16h |
| 31 | 8.3 | Finalize opening date | milestone | 0d | 2005-11-04 | 2005-11-04 |  | 0d | Your name |  |
| 32 | 8.4 | Send invitations |  | 2d | 2005-11-07 | 2005-11-08 | 31 | 0d | Your name | 16h |
